# projekty

Schedule from MS Project, 2013-08-01 to 2014-12-15.
SUDOP PRAHA a.s.

## Calendars

- Standardní: Mon-Sun 08:00-12:00, 13:00-17:00.

## Schedule

| ID | WBS | Task | Duration | Start | Finish | Predecessors | Total slack | Constraint |
| --- | --- | --- | --- | --- | --- | --- | --- | --- |
| 1 | 1 | **Modernizace trati Veselí n.L. - Tábor - II.část, úsek Veselí n.L. - Doubí u Tábora, 1. etapa Veselí n/L - Soběslav** | 502d | 2013-08-01 | 2014-12-15 |  | 0d |  |
| 2 | 1.1 | **TÚ Veselí n.L. - Soběslav** | 502d | 2013-08-01 | 2014-12-15 |  | 0d |  |
| 4 | 1.1.1 | Přípravné práce | 122d | 2013-08-01 | 2013-11-30 |  | 0d | start no earlier than 2013-08-01 |
| 6 | 1.1.2 | Technologická přestávka | 90d | 2013-12-01 | 2014-02-28 | 4 | 0d |  |
| 8 | 1.1.3 | Přípravné práce | 31d | 2014-03-01 | 2014-03-31 | 6 | 0d |  |
| 9 | 1.1.4 | Stavební postup č. 1.1 | 92d | 2014-04-01 | 2014-07-01 | 8 | 0d | start no earlier than 2013-03-01 |
| 10 | 1.1.5 | Stavební postup č. 1.2 | 31d | 2014-07-02 | 2014-08-01 | 9 | 0d | finish no earlier than 2013-06-21 |
| 11 | 1.1.6 | Stavební postup č. 1.3 | 21d | 2014-08-02 | 2014-08-22 | 10 | 0d | finish no earlier than 2013-06-21 |
| 12 | 1.1.7 | Stavební postup č. 1.4 | 93d | 2014-08-23 | 2014-11-23 | 11 | 0d | start no earlier than 2013-06-22 |
| 14 | 1.1.8 | Dokončovací práce | 22d | 2014-11-24 | 2014-12-15 | 12 | 0d |  |
| 16 | 1.2 | **ŽST Soběslav** | 502d | 2013-08-01 | 2014-12-15 |  | 0d |  |
| 18 | 1.2.1 | Přípravné práce | 122d | 2013-08-01 | 2013-11-30 |  | 0d | start no earlier than 2013-08-01 |
| 20 | 1.2.2 | Technologická přestávka | 90d | 2013-12-01 | 2014-02-28 | 18 | 0d |  |
| 22 | 1.2.3 | Přípravné práce | 31d | 2014-03-01 | 2014-03-31 | 20 | 0d |  |
| 23 | 1.2.4 | Stavební postup č. 2.1 | 92d | 2014-04-01 | 2014-07-01 | 22 | 0d | start no earlier than 2013-04-01 |
| 24 | 1.2.5 | Stavební postup č. 2.2 | 31d | 2014-07-02 | 2014-08-01 | 23 | 0d | start no earlier than 2013-07-01 |
| 25 | 1.2.6 | Stavební postup č. 2.3 | 21d | 2014-08-02 | 2014-08-22 | 24 | 0d |  |
| 26 | 1.2.7 | Stavební postup č. 2.4 | 93d | 2014-08-23 | 2014-11-23 | 25 | 0d | start no earlier than 2013-10-31 |
| 28 | 1.2.8 | Dokončovací práce | 22d | 2014-11-24 | 2014-12-15 | 26 | 0d |  |
